# GD-05 - gevelpanelen+dakplaten

Schedule from MS Project, 2003-01-12 to 2003-01-26, status date 2003-01-08.
BAM Nelissen Van Egteren

## Calendars

- ALLEEN WERKDAGEN: Mon-Fri 08:30-12:30, 13:00-17:00; Sat-Sun off. Exceptions (off unless hours are given): 2003-01-11 to 2003-01-12 08:30-12:30, 13:00-17:00, 2003-01-18 to 2003-01-19 08:30-12:30, 13:00-17:00, 2003-01-25 to 2003-01-26 08:30-12:30, 13:00-17:00.

## Schedule

| ID | WBS | Task | Type | Duration | Start | Finish | Predecessors | Total slack | Free slack |
| --- | --- | --- | --- | --- | --- | --- | --- | --- | --- |
| 1 | 1 | **BOVENBOUWFASE** |  | 15d | 2003-01-12 | 2003-01-26 |  | 0d |  |
| 2 | 1.1 | gevelpanelen monteren |  | 10d | 2003-01-12 | 2003-01-21 |  | 3d | 0d |
| 3 | 1.2 | buitenkozijnen+deuren stellen |  | 4d | 2003-01-19 | 2003-01-22 | 2SS+7d | 3d | 0d |
| 4 | 1.3 | glas zetten in gevel |  | 3d | 2003-01-21 | 2003-01-23 | 3SS+2d | 3d |  |
| 5 | 1.4 | stalen dakplaten monteren |  | 10d | 2003-01-12 | 2003-01-21 |  | 0d |  |
| 6 | 1.5 | dakramen+dakdoorvoeren |  | 4d | 2003-01-19 | 2003-01-22 | 5SS+7d | 0d |  |
| 7 | 1.6 | dakisolatie aanbrengen |  | 4d | 2003-01-21 | 2003-01-24 | 6SS+2d | 0d |  |
| 8 | 1.7 | dakbedekking aanbrengen |  | 4d | 2003-01-23 | 2003-01-26 | 7SS+2d | 0d |  |
| 9 | 1.8 | start afbouw fase | milestone | 0d | 2003-01-26 | 2003-01-26 | 8SS+4d | 0d |  |
